# SOW 3.1 Project Plan v1

Schedule from MS Project, 2002-06-01 to 2003-06-18, A marks actual dates.
NeuStar, Inc.

## Calendars

- Standard: Mon-Fri 08:00-12:00, 13:00-17:00; Sat-Sun off. Exceptions (off unless hours are given): 2002-06-08 to 2002-06-09 08:00-12:00, 13:00-17:00, 2003-03-29 08:00-12:00, 13:00-17:00, 2003-04-12 08:00-12:00, 13:00-17:00, 2003-04-26 to 2003-04-27 08:00-12:00, 13:00-17:00, 2003-05-11 08:00-12:00, 13:00-17:00, 2003-05-18 08:00-12:00, 13:00-17:00, 2003-05-25 08:00-12:00, 13:00-17:00, 2003-06-01 08:00-12:00, 13:00-17:00, 2003-06-15 08:00-12:00, 13:00-17:00.

## Resources

| Resource |
| --- |
| NeuStar |
| ESI |
| NeuStar |
| Industry |
| In |
| TSE |
| LNPA |
| LNPA Co Chair |
| All |
| NE Region |
| Super Region |
| NeuStar |
| ACGS |
| Mantiss |
| TTI |
| MCIW |
| ATT |
| Inlogic |
| Lucent |
| Telcordia |
| Tekelec |
| Connection |
| NE |
| NE Technologies |
| LNPA WG |
| Vendors |
| SPs |
| WCOM |
| Industry |
| Region 2 |
| NAPM LLC |
| Region 3 |
| Region 4 |
| Region 5 |
| NPAM LLC |
| Region 6 |
| Region 7 |
| NeuStar Service Delivery |
| NeuStar |
| Raviant |
| NeuStar |
| Illuminet |
| Ky |
| NeuStar (Ky) |
| NeuStat |
| NeuStar Engineering |
| All SPs |
| SPs and NeuStar |
| NeuStar/Industry |
| NeuStar & vendors |

## Schedule

| ID | WBS | Task | Type | Duration | Start | Finish | Complete | Remaining | Total slack | Constraint | Resources | Work | Actual work |
| --- | --- | --- | --- | --- | --- | --- | --- | --- | --- | --- | --- | --- | --- |
| 1 | 1 | **NPAC Release 3.2 Implementation** |  | 284d | 2002-06-01 A | 2003-06-18 | 75% | 70.67d | 0d |  |  | 6912h | 4969.6h |
| 2 | 1.1 | **Phase 1.0** |  | 217d | 2002-06-01 A | 2003-03-28 | 93% | 14.43d | 67d |  |  | 4672h | 4372h |
| 3 | 1.1.1 | Effective Start Date | milestone | 0d | 2002-06-01 A | 2002-06-01 A | 100% |  |  | start no earlier than 2001-07-16 |  |  |  |
| 4 | 1.1.2 | Release Package to NAPM LLC |  | 1d | 2002-06-01 A | 2002-06-03 A | 100% |  |  | start no earlier than 2001-07-16 | LNPA Co Chair | 8h | 8h |
| 5 | 1.1.3 | SOW Effective Date | milestone | 0d | 2002-06-30 A | 2002-06-30 A | 100% |  |  | start no earlier than 2001-08-24 | Industry; NeuStar |  |  |
| 6 | 1.1.4 | **Phase 1.1 Develop SOW Project Plan** |  | 35d | 2002-08-01 A | 2002-09-18 A | 100% |  |  |  |  | 504h | 504h |
| 7 | 1.1.4.1 | Draft Project Plan delivered to LLC |  | 1d | 2002-08-01 A | 2002-08-01 A | 100% |  |  | start no earlier than 2002-08-01 | NeuStar | 8h | 8h |
| 8 | 1.1.4.2 | Project Plan - Review |  | 8d | 2002-08-01 A | 2002-08-12 A | 100% |  |  | start no earlier than 2002-08-01 | LNPA | 64h | 64h |
| 9 | 1.1.4.3 | Project Plan Final Delivery |  | 27d | 2002-08-13 A | 2002-09-18 A | 100% |  |  | finish no earlier than 2002-09-18 | LNPA; NeuStar | 432h | 432h |
| 10 | 1.1.5 | **Phase 1.2 Design and Develop Enhancement** |  | 217d | 2002-06-03 A | 2003-03-28 | 95% | 11.61d | 67d |  |  | 1784h | 1680h |
| 11 | 1.1.5.1 | **GDMO/ASN.1 Spec Completion** |  | 24d | 2002-07-24 A | 2002-08-26 A | 100% |  |  |  |  | 72h | 72h |
| 12 | 1.1.5.1.1 | GDMO/ASN.1 Draft #1 published on web site |  | 1d | 2002-07-24 A | 2002-07-24 A | 100% |  |  | start no earlier than 2002-07-24 | NeuStar | 8h | 8h |
| 13 | 1.1.5.1.2 | GDMO/ASN.1 Draft #1 review period by Industry |  | 4d | 2002-07-25 A | 2002-07-30 A | 100% |  |  | start no earlier than 2002-07-25 | Industry | 32h | 32h |
| 14 | 1.1.5.1.3 | GDMO/ASN.1 Draft #2 published on web site |  | 1d | 2002-08-22 A | 2002-08-22 A | 100% |  |  | start no earlier than 2002-08-22 | NeuStar | 8h | 8h |
| 15 | 1.1.5.1.4 | GDMO/ASN.1 Draft #2 review period by Industry |  | 2d | 2002-08-23 A | 2002-08-26 A | 100% |  |  | start no earlier than 2002-08-23 | Industry | 16h | 16h |
| 16 | 1.1.5.1.5 | GDMO/ASN.1 Final Version distributed |  | 1d | 2002-08-26 A | 2002-08-26 A | 100% |  |  | start no earlier than 2002-08-26 | NeuStar | 8h | 8h |
| 17 | 1.1.5.2 | **FRS Integrated Document Completion** |  | 40d | 2002-08-09 A | 2002-10-03 A | 100% |  |  |  |  | 152h | 152h |
| 18 | 1.1.5.2.1 | FRS Draft #1 Integrated Document distributed to Industry |  | 1d | 2002-08-09 A | 2002-08-09 A | 100% |  |  | start no earlier than 2002-08-09 | NeuStar | 8h | 8h |
| 19 | 1.1.5.2.2 | FRS Draft #1 review period by Industry |  | 5d | 2002-08-12 A | 2002-08-16 A | 100% |  |  | start no earlier than 2002-08-12 | Industry | 40h | 40h |
| 20 | 1.1.5.2.3 | FRS Draft #2 Integrated Document distributed to Industry |  | 1d | 2002-09-03 A | 2002-09-03 A | 100% |  |  | start no earlier than 2002-09-03 | NeuStar | 8h | 8h |
| 21 | 1.1.5.2.4 | FRS Draft #2 review period by Industry |  | 11d | 2002-09-04 A | 2002-09-18 A | 100% |  |  | start no earlier than 2002-09-04 | Industry | 88h | 88h |
| 22 | 1.1.5.2.5 | FRS Proposed Final Integrated Document |  | 1d | 2002-09-23 A | 2002-09-23 A | 100% |  |  | start no earlier than 2002-09-23 |  |  |  |
| 23 | 1.1.5.2.6 | FRS Final Integrated Document (3.2.0a) |  | 1d | 2002-10-03 A | 2002-10-03 A | 100% |  |  | start no earlier than 2002-09-23 | NeuStar | 8h | 8h |
| 24 | 1.1.5.3 | **IIS Integrated Document Completion** |  | 33d | 2002-09-06 A | 2002-10-22 A | 100% |  |  |  |  | 160h | 160h |
| 25 | 1.1.5.3.1 | IIS Draft #1 Integrated Document distributed to Industry |  | 1d | 2002-09-06 A | 2002-09-06 A | 100% |  |  | start no earlier than 2002-09-06 | NeuStar | 8h | 8h |
| 26 | 1.1.5.3.2 | IIS Draft #1 review period by Industry |  | 8d | 2002-09-09 A | 2002-09-18 A | 100% |  |  | start no earlier than 2002-09-09 | Industry | 64h | 64h |
| 27 | 1.1.5.3.3 | IIS Draft #2 Integrated Document distributed to Industry (3.2.0a) |  | 1d | 2002-10-03 A | 2002-10-03 A | 100% |  |  | start no earlier than 2002-10-03 | NeuStar | 8h | 8h |
| 28 | 1.1.5.3.4 | IIS Draft #2 review period by Industry (3.2.0a) |  | 9d | 2002-10-04 A | 2002-10-16 A | 100% |  |  | finish no earlier than 2002-10-16 | Industry | 72h | 72h |
| 29 | 1.1.5.3.5 | IIS Final Integrated Document (3.2.0a) Review produced no changes. |  | 1d | 2002-10-22 A | 2002-10-22 A | 100% |  |  | start no earlier than 2002-10-22 | NeuStar | 8h | 8h |

| ID | WBS | Task | Type | Duration | Start | Finish | Complete | Remaining | Total slack | Constraint | Resources | Work | Actual work |
| --- | --- | --- | --- | --- | --- | --- | --- | --- | --- | --- | --- | --- | --- |
| 30 | 1.1.5.4 | **M&P Development Completion** |  | 26d | 2003-02-21 | 2003-03-28 |  |  | 67d |  |  | 104h |  |
| 31 | 1.1.5.4.1 | M&Ps Draft #1 distributed to Industry |  | 1d | 2003-02-21 | 2003-02-21 |  |  | 90d | start no earlier than 2003-02-21 | NeuStar | 8h |  |
| 32 | 1.1.5.4.2 | M&Ps Draft #1 review period by Industry |  | 5d | 2003-02-24 | 2003-02-28 |  |  | 85d | start no earlier than 2003-02-24 | Industry | 40h |  |
| 33 | 1.1.5.4.3 | M&Ps Draft #2 distributed to Industry |  | 1d | 2003-03-13 | 2003-03-13 |  |  | 76d | start no earlier than 2003-03-13 | NeuStar | 8h |  |
| 34 | 1.1.5.4.4 | M&Ps Draft #2 review period by Industry |  | 5d | 2003-03-14 | 2003-03-20 |  |  | 71d | start no earlier than 2003-03-14 | Industry | 40h |  |
| 35 | 1.1.5.4.5 | FINAL Publishing of M&Ps (SLR 26) |  | 1d | 2003-03-28 | 2003-03-28 |  |  | 65d | start no earlier than 2003-03-28 | NeuStar | 8h |  |
| 36 | 1.1.5.5 | Delta Change Order document completed |  | 19d | 2002-09-09 A | 2002-10-03 A | 100% |  |  | start no earlier than 2002-09-09 |  |  |  |
| 37 | 1.1.5.6 | Release 3.2 Development Completed |  | 162d | 2002-06-03 A | 2003-01-10 A | 100% |  |  | finish no earlier than 2003-01-10 | NeuStar | 1296h | 1296h |
| 38 | 1.1.6 | **Phase 1.3 IT&S Testing of the Enhancement** |  | 121d | 2002-09-16 A | 2003-03-03 | 89% | 13.64d | 86d |  |  | 800h | 716h |
| 39 | 1.1.6.1 | Develop Test Cases |  | 65d | 2002-09-16 A | 2002-12-13 A | 100% |  |  | start no earlier than 2002-09-16 | NeuStar | 520h | 520h |
| 40 | 1.1.6.2 | Execute Internal testing |  | 35d | 2003-01-13 A | 2003-02-28 | 70% | 10.5d | 87d | start no earlier than 2003-01-13 | NeuStar | 280h | 196h |
| 41 | 1.1.6.3 | NeuStar Software Certification and install on Test bed | milestone | 1d | 2003-03-03 | 2003-03-03 |  |  | 68d | start no earlier than 2003-03-03 |  |  |  |
| 42 | 1.1.6.4 | Notification of requirements to pass edits to 191, 291, and 319 |  | 1d | 2003-01-13 A | 2003-01-13 A | 100% |  |  | finish no earlier than 2003-01-13 |  |  |  |
| 43 | 1.1.7 | **Phase 1.4 Interoperability Testing** |  | 164d | 2002-07-15 A | 2003-02-27 | 93% | 11.65d | 88d |  |  | 1576h | 1464h |
| 44 | 1.1.7.1 | **Interoperability and Test Cases Completion** |  | 80d | 2002-08-08 A | 2002-11-27 A | 100% |  |  |  |  | 448h | 448h |
| 45 | 1.1.7.1.1 | ITP Test Case List Draft #1 distributed to Industry |  | 1d | 2002-08-08 A | 2002-08-08 A | 100% |  |  | start no earlier than 2002-08-08 | NeuStar | 8h | 8h |
| 46 | 1.1.7.1.2 | ITP Test Case List Draft #1 review period by Industry |  | 21d | 2002-08-09 A | 2002-09-06 A | 100% |  |  | start no earlier than 2002-08-09 | Industry | 168h | 168h |
| 47 | 1.1.7.1.3 | ITP Test Case List Draft #2 distributed to Industry |  | 1d | 2002-09-19 A | 2002-09-19 A | 100% |  |  | start no earlier than 2002-09-19 | NeuStar | 8h | 8h |
| 48 | 1.1.7.1.4 | ITP Test Case List Draft #2 review period by Industry |  | 10d | 2002-09-20 A | 2002-10-03 A | 100% |  |  | start no earlier than 2002-09-20 | Industry | 80h | 80h |
| 49 | 1.1.7.1.5 | ITP Test Cases - Draft #1 - distributed to Industry |  | 1d | 2002-10-16 A | 2002-10-16 A | 100% |  |  | start no earlier than 2002-10-16 | NeuStar | 8h | 8h |
| 50 | 1.1.7.1.6 | ITP Test Cases - Draft #1 - review period by Industry |  | 11d | 2002-10-17 A | 2002-10-31 A | 100% |  |  | start no earlier than 2002-10-17 | Industry | 88h | 88h |
| 51 | 1.1.7.1.7 | ITP Test Cases - Draft #2 - distributed to Industry |  | 1d | 2002-11-12 A | 2002-11-12 A | 100% |  |  | start no earlier than 2002-11-12 | NeuStar | 8h | 8h |
| 52 | 1.1.7.1.8 | ITP Test Cases - Draft #2 review period by Industry |  | 9d | 2002-11-13 A | 2002-11-25 A | 100% |  |  | start no earlier than 2002-11-13 | Industry | 72h | 72h |
| 53 | 1.1.7.1.9 | FINAL Publishing of ITP Test Case |  | 1d | 2002-11-27 A | 2002-11-27 A | 100% |  |  | start no earlier than 2002-11-27 | NeuStar | 8h | 8h |

| ID | WBS | Task | Type | Duration | Start | Finish | Complete | Remaining | Total slack | Constraint | Resources | Work | Actual work |
| --- | --- | --- | --- | --- | --- | --- | --- | --- | --- | --- | --- | --- | --- |
| 54 | 1.1.7.2 | **ITP Simulator Upgrade** |  | 160d | 2002-07-15 A | 2003-02-21 | 91% | 15d | 92d |  | NE Technologies | 1024h | 928h |
| 55 | 1.1.7.2.1 | Analyze and Design changes to GDMO and ASN.1 |  | 25d | 2002-07-15 A | 2002-08-16 A | 100% |  |  | finish no earlier than 2002-08-16 | NE Technologies | 200h | 200h |
| 56 | 1.1.7.2.2 | Coding of changes |  | 22d | 2002-08-16 A | 2002-09-16 A | 100% |  |  | start no earlier than 2002-08-16 | NE Technologies | 176h | 176h |
| 57 | 1.1.7.2.3 | Testing Modified ITP |  | 20d | 2002-09-16 A | 2002-10-11 A | 100% |  |  | finish no earlier than 2002-10-11 | NE Technologies | 160h | 160h |
| 58 | 1.1.7.2.4 | Training to NeuStar |  | 1d | 2002-11-01 A | 2002-11-01 A | 100% |  |  | start no earlier than 2002-11-01 | NE Technologies | 8h | 8h |
| 59 | 1.1.7.2.5 | Interoperability Test Execution with Vendors |  | 60d | 2002-12-02 A | 2003-02-21 | 80% | 12d | 92d | finish no earlier than 2003-02-21 | NeuStar & vendors | 480h | 384h |
| 60 | 1.1.7.3 | **ITP Testing Communication Plan** |  | 61d | 2002-12-05 A | 2003-02-27 | 85% | 9.38d | 88d |  |  | 104h | 88h |
| 61 | 1.1.7.3.1 | Weekly SP/Vendor ITP Conference call |  | 1d | 2002-12-05 A | 2002-12-05 A | 100% |  |  | start no earlier than 2002-12-05 | NeuStar | 8h | 8h |
| 62 | 1.1.7.3.2 | Weekly SP/Vendor ITP Conference Call |  | 1d | 2002-12-12 A | 2002-12-12 A | 100% |  |  | start no earlier than 2002-12-12 | NeuStar | 8h | 8h |
| 63 | 1.1.7.3.3 | Weekly SP/Vendor ITP Conference call |  | 1d | 2002-12-19 A | 2002-12-19 A | 100% |  |  | start no earlier than 2002-12-19 | NeuStar | 8h | 8h |
| 64 | 1.1.7.3.4 | Weekly SP/Vendor ITP Conference call |  | 1d | 2002-12-26 A | 2002-12-26 A | 100% |  |  | start no earlier than 2002-12-26 | NeuStar | 8h | 8h |
| 65 | 1.1.7.3.5 | Weekly SP/Vendor ITP Conference call |  | 1d | 2003-01-02 A | 2003-01-02 A | 100% |  |  | start no earlier than 2003-01-02 | NeuStar | 8h | 8h |
| 66 | 1.1.7.3.6 | Weekly SP/Vendor ITP Conference call |  | 1d | 2003-01-09 A | 2003-01-09 A | 100% |  |  | start no earlier than 2003-01-09 | NeuStar | 8h | 8h |
| 67 | 1.1.7.3.7 | Weekly SP/Vendor ITP Conference Call |  | 1d | 2003-01-16 A | 2003-01-16 A | 100% |  |  | start no earlier than 2003-01-16 | NeuStar | 8h | 8h |
| 68 | 1.1.7.3.8 | Weekly SP/Vendor ITP Conference Call |  | 1d | 2003-01-30 A | 2003-01-30 A | 100% |  |  |  | NeuStar | 8h | 8h |
| 69 | 1.1.7.3.9 | Weekly SP/Vendor ITP Conference Call |  | 1d | 2003-01-30 A | 2003-01-30 A | 100% |  |  | start no earlier than 2003-01-30 | NeuStar | 8h | 8h |
| 70 | 1.1.7.3.10 | Weekly SP/Vendor ITP Conference Call |  | 1d | 2003-02-06 A | 2003-02-06 A | 100% |  |  | start no earlier than 2003-02-06 | NeuStar | 8h | 8h |
| 71 | 1.1.7.3.11 | Weekly SP/Vendor ITP Conference Call |  | 1d | 2003-02-13 A | 2003-02-13 A | 100% |  |  | start no earlier than 2003-02-13 | NeuStar | 8h | 8h |
| 72 | 1.1.7.3.12 | Weekly SP/Vendor ITP Conference Call |  | 1d | 2003-02-20 | 2003-02-20 |  |  | 93d | start no earlier than 2003-02-20 | NeuStar | 8h |  |
| 73 | 1.1.7.3.13 | Weekly SP/Vendor ITP Conference Call |  | 1d | 2003-02-27 | 2003-02-27 |  |  | 88d | start no earlier than 2003-02-27 | NeuStar | 8h |  |
| 74 | 1.2 | **Phase 2.0 Turn Up Testing Of Enhancement** |  | 206d | 2002-08-09 A | 2003-05-16 | 38% | 128.62d | 27d |  |  | 2048h | 592h |
| 75 | 1.2.1 | **Phase 2.1 Turn Up Test Plan and Test Case Completion** |  | 147d | 2002-08-09 A | 2003-03-03 | 85% | 21.97d | 86d |  |  | 696h | 592h |
| 76 | 1.2.1.1 | Turn Up Test Case List Draft #1 distributed to Industry |  | 1d | 2002-08-09 A | 2002-08-09 A | 100% |  |  | start no earlier than 2002-08-09 | NeuStar | 8h | 8h |
| 77 | 1.2.1.2 | Turn Up Test Case List review period by Industry |  | 27d | 2002-08-13 A | 2002-09-18 A | 100% |  |  | start no earlier than 2002-08-13 | Industry | 216h | 216h |
| 78 | 1.2.1.3 | Turn Up Test Case List Draft #2 distributed to Industry |  | 1d | 2002-10-08 A | 2002-10-08 A | 100% |  |  | start no earlier than 2002-10-08 | NeuStar | 8h | 8h |
| 79 | 1.2.1.4 | Turn Up Test Case List Draft #2 review period by Industry |  | 10d | 2002-10-09 A | 2002-10-22 A | 100% |  |  | start no earlier than 2002-10-09 | Industry | 80h | 80h |
| 80 | 1.2.1.5 | Turn Up Test Cases - Draft #1 distributed to Industry |  | 1d | 2002-11-22 A | 2002-11-22 A | 100% |  |  | start no earlier than 2002-11-22 | NeuStar | 8h | 8h |
| 81 | 1.2.1.6 | Turn Up Test Cases - Draft #1 review period by Industry |  | 16d | 2002-11-25 A | 2002-12-16 A | 100% |  |  | finish no earlier than 2002-12-16 | Industry | 128h | 128h |
| 82 | 1.2.1.7 | Turn UP Test Cases - Review Conf call |  | 2d | 2002-12-17 A | 2002-12-18 A | 100% |  |  | start no earlier than 2002-12-17 | NeuStar/Industry | 16h | 16h |
| 83 | 1.2.1.8 | Turn Up Test Cases - Draft #2 distributed to Industry |  | 1d | 2003-01-17 A | 2003-01-17 A | 100% |  |  | start no earlier than 2003-01-17 | NeuStar | 8h | 8h |
| 84 | 1.2.1.9 | Turn Up Test Cases - Draft #2 review period by Industry |  | 15d | 2003-01-20 A | 2003-02-07 A | 100% |  |  | start no earlier than 2003-01-20 | Industry | 120h | 120h |
| 85 | 1.2.1.10 | FINAL Publishing of Turn Up Test Plan for R3.2 |  | 1d | 2003-02-14 | 2003-02-14 |  |  | 97d | start no earlier than 2003-02-14 | NeuStar | 8h |  |
| 86 | 1.2.1.11 | SP Certification & Regression Test Plan with mods for R3.2, distributed to Industry |  | 1d | 2003-02-18 | 2003-02-18 |  |  | 95d | finish no earlier than 2003-02-18 | NeuStar | 8h |  |
| 87 | 1.2.1.12 | SP Certification & Regression Test Plan with mods for R3.2, review period by Industry |  | 10d | 2003-02-18 | 2003-03-03 |  |  | 86d | finish no earlier than 2003-03-03 | Industry | 80h |  |
| 88 | 1.2.1.13 | FINAL Publishing of Turn Up Test Plan, REGRESSION PORTION | milestone | 1d | 2003-03-03 | 2003-03-03 |  |  | 86d | finish no earlier than 2003-03-03 | NeuStar | 8h |  |

| ID | WBS | Task | Type | Duration | Start | Finish | Predecessors | Complete | Remaining | Total slack | Free slack | Constraint | Resources | Work | Actual work |
| --- | --- | --- | --- | --- | --- | --- | --- | --- | --- | --- | --- | --- | --- | --- | --- |
| 89 | 1.2.2 | **Phase 2.2 Turn Up Test Execution** |  | 69d | 2003-02-18 | 2003-05-16 |  |  |  | 27d |  |  |  | 1352h |  |
| 90 | 1.2.2.1 | Sample BDD and SMURF files distributed for NANC 169, 354, and 323 |  | 1d | 2003-02-18 | 2003-02-18 |  |  |  | 95d |  | start no earlier than 2003-02-18 |  |  |  |
| 91 | 1.2.2.2 | **Turn Up Testing Communication Plan** |  | 57d | 2003-03-05 | 2003-05-15 |  |  |  | 28d |  |  |  | 408h |  |
| 92 | 1.2.2.2.1 | Daily TUT Status reports |  | 40d | 2003-03-05 | 2003-04-25 |  |  |  | 45d |  | finish no earlier than 2003-04-25 | NeuStar | 320h |  |
| 93 | 1.2.2.2.2 | Weekly SP TUT Conference call | milestone | 1d | 2003-03-06 | 2003-03-06 |  |  |  | 83d |  | start no earlier than 2003-03-06 | NeuStar | 8h |  |
| 94 | 1.2.2.2.3 | Weekly SP TUT Conference call | milestone | 1d | 2003-03-13 | 2003-03-13 |  |  |  | 78d |  | start no earlier than 2003-03-13 | NeuStar | 8h |  |
| 95 | 1.2.2.2.4 | Weekly SP TUT Conference call | milestone | 1d | 2003-03-20 | 2003-03-20 |  |  |  | 73d |  | start no earlier than 2003-03-20 | NeuStar | 8h |  |
| 96 | 1.2.2.2.5 | Weekly SP TUT Conference call | milestone | 1d | 2003-03-27 | 2003-03-27 |  |  |  | 68d |  | start no earlier than 2003-03-27 | NeuStar | 8h |  |
| 97 | 1.2.2.2.6 | Weekly SP TUT Conference call | milestone | 1d | 2003-04-03 | 2003-04-03 |  |  |  | 62d |  | start no earlier than 2003-04-03 | NeuStar | 8h |  |
| 98 | 1.2.2.2.7 | Weekly SP TUT Conference call | milestone | 1d | 2003-04-10 | 2003-04-10 |  |  |  | 57d |  | start no earlier than 2003-04-10 | NeuStar | 8h |  |
| 99 | 1.2.2.2.8 | Weekly SP TUT Conference call | milestone | 1d | 2003-04-17 | 2003-04-17 |  |  |  | 51d |  | start no earlier than 2003-04-17 | NeuStar | 8h |  |
| 100 | 1.2.2.2.9 | Weekly SP TUT Conference call | milestone | 1d | 2003-04-24 | 2003-04-24 |  |  |  | 46d |  | start no earlier than 2003-04-24 | NeuStar | 8h |  |
| 101 | 1.2.2.2.10 | Weekly SP TUT Conference call |  | 1d | 2003-05-01 | 2003-05-01 |  |  |  | 39d |  | start no earlier than 2003-05-01 | NeuStar | 8h |  |
| 102 | 1.2.2.2.11 | Weekly SP TUT Conference call |  | 1d | 2003-05-08 | 2003-05-08 |  |  |  | 34d |  | start no earlier than 2003-05-08 | NeuStar | 8h |  |
| 103 | 1.2.2.2.12 | Weekly SP TUT Conference call |  | 1d | 2003-05-15 | 2003-05-15 |  |  |  | 28d |  | start no earlier than 2003-05-15 | NeuStar | 8h |  |
| 104 | 1.2.2.3 | **SP Release 3.2 Testing** |  | 60d | 2003-03-03 | 2003-05-16 |  |  |  | 27d |  |  | All SPs | 944h |  |
| 105 | 1.2.2.3.1 | SP Individual Testing Session |  | 42d | 2003-03-03 | 2003-04-25 |  |  |  | 31d | 2d | start no earlier than 2003-03-03 | All SPs | 336h |  |
| 106 | 1.2.2.3.2 | SP Group and Performance Testing |  | 14d | 2003-04-28 | 2003-05-14 | 105 |  |  | 29d |  | finish no earlier than 2003-05-14 | All SPs | 112h |  |
| 107 | 1.2.2.3.3 | SP Failover Testing |  | 2d | 2003-05-15 | 2003-05-16 |  |  |  | 27d |  | start no earlier than 2003-05-15 | All SPs | 16h |  |
| 108 | 1.3 | **Phase 3.0 Roll Out of Enhancement** |  | 128d | 2003-01-03 A | 2003-06-18 |  | 2% | 125.92d | 0d |  |  |  | 192h | 5.6h |
| 109 | 1.3.1 | EMW (Enhanced Maintenance Window) Blanket Request Completion |  | 1d | 2003-01-03 A | 2003-01-03 |  | 70% | 0.3d | 127d |  | start no earlier than 2003-01-03 | NeuStar | 8h | 5.6h |
| 110 | 1.3.2 | Notification of delivery to Industry (SLR 24) |  | 1d | 2003-03-07 | 2003-03-07 |  |  |  | 82d |  | start no earlier than 2003-03-07 | NeuStar Service Delivery | 8h |  |
| 111 | 1.3.3 | LLC/PEs Identify sequence of region installation |  | 1d | 2003-03-21 | 2003-03-21 |  |  |  | 72d |  | start no earlier than 2003-03-21 | NAPM LLC | 8h |  |
| 112 | 1.3.4 | **Region 1 Install 3.2 Release** |  | 36d | 2003-04-18 | 2003-05-30 |  |  |  | 15d |  |  |  | 56h |  |
| 113 | 1.3.4.1 | Provide 30 day notification |  | 1d | 2003-04-18 | 2003-04-18 |  |  |  | 50d |  | start no earlier than 2003-04-18 | NeuStar | 8h |  |
| 114 | 1.3.4.2 | Send out SP Profile Questionaire |  | 1d | 2003-04-28 | 2003-04-28 |  |  |  | 42d |  | start no earlier than 2003-04-28 | NeuStar | 8h |  |
| 115 | 1.3.4.3 | Preliminary Go/No Go Decision |  | 1d | 2003-05-02 | 2003-05-02 |  |  |  | 38d |  | start no earlier than 2003-05-02 | NeuStar/Industry | 8h |  |
| 116 | 1.3.4.4 | SPs profile information due to NeuStar |  | 1d | 2003-05-05 | 2003-05-05 |  |  |  | 37d |  | start no earlier than 2003-05-05 | SPs; NeuStar | 16h |  |
| 117 | 1.3.4.5 | NPAC Taken down for H/w S/w install |  | 1d | 2003-05-18 | 2003-05-18 |  |  |  | 26d |  | start no earlier than 2003-05-18 | NeuStar | 8h |  |
| 118 | 1.3.4.6 | Region 1 Final Go-NoGo decision | milestone | 0d | 2003-05-18 | 2003-05-18 |  |  |  | 27d |  | start no earlier than 2003-05-18 | SPs and NeuStar |  |  |
| 119 | 1.3.4.7 | Install Rel 3.2 Production Software |  | 1d | 2003-05-18 | 2003-05-18 |  |  |  | 26d |  | start no earlier than 2003-05-18 | NeuStar | 8h |  |
| 120 | 1.3.4.8 | Region 1 General Availability | milestone | 0d | 2003-05-19 | 2003-05-19 |  |  |  | 26d |  | start no earlier than 2003-05-19 |  |  |  |
| 121 | 1.3.4.9 | Region 1 Contigency Plan conference call | milestone | 0d | 2003-05-19 | 2003-05-19 |  |  |  | 26d |  | start no earlier than 2003-05-19 | SPs and NeuStar |  |  |
| 122 | 1.3.4.10 | Region 1 Soak Period |  | 11d | 2003-05-19 | 2003-05-30 |  |  |  | 15d |  | start no earlier than 2003-05-19 |  |  |  |

| ID | WBS | Task | Type | Duration | Start | Finish | Total slack | Constraint | Resources | Work |
| --- | --- | --- | --- | --- | --- | --- | --- | --- | --- | --- |
| 124 | 1.3.5 | **Regions 2,3 and 4 Install 3.2 Release** |  | 35d | 2003-05-02 | 2003-06-13 | 4d |  |  | 48h |
| 125 | 1.3.5.1 | Provide 30 day notification |  | 1d | 2003-05-02 | 2003-05-02 | 38d | start no earlier than 2003-05-02 | NeuStar | 8h |
| 126 | 1.3.5.2 | Send out SP Profile Questionaire |  | 1d | 2003-05-12 | 2003-05-12 | 31d | start no earlier than 2003-05-12 | NeuStar | 8h |
| 127 | 1.3.5.3 | Preliminary Go/No Go decision |  | 1d | 2003-05-16 | 2003-05-16 | 27d | start no earlier than 2003-05-16 | NeuStar/Industry | 8h |
| 128 | 1.3.5.4 | SPs profile information due to NeuStar |  | 1d | 2003-05-19 | 2003-05-19 | 25d | start no earlier than 2003-05-19 | SPs; NeuStar | 16h |
| 129 | 1.3.5.5 | NPAC Taken down for H/w S/w install |  | 1d | 2003-06-01 | 2003-06-01 | 14d | start no earlier than 2003-06-01 | NeuStar | 8h |
| 130 | 1.3.5.6 | Regions 2,3 and 4 Final Go-NoGo decision | milestone | 0d | 2003-06-01 | 2003-06-01 | 15d | start no earlier than 2003-06-01 | SPs and NeuStar |  |
| 131 | 1.3.5.7 | Install Rel 3.2 Production Software | milestone | 0d | 2003-06-01 | 2003-06-01 | 15d | start no earlier than 2003-06-01 | NeuStar |  |
| 132 | 1.3.5.8 | Regions 2,3 and 4 General Availability | milestone | 0d | 2003-06-02 | 2003-06-02 | 14d | start no earlier than 2003-06-02 |  |  |
| 133 | 1.3.5.9 | Regions 2,3 and 4 Contigency Plan conference call | milestone | 0d | 2003-06-02 | 2003-06-02 | 14d | start no earlier than 2003-06-02 | SPs and NeuStar |  |
| 134 | 1.3.5.10 | Regions 2,3 and 4 Soak Period |  | 10d | 2003-06-02 | 2003-06-13 | 4d | start no earlier than 2003-06-02 |  |  |
| 136 | 1.3.6 | **Regions 5,6 and 7 Install 3.2 Release** |  | 26d | 2003-05-16 | 2003-06-16 | 2d |  |  | 64h |
| 137 | 1.3.6.1 | Provide 30 day notification |  | 1d | 2003-05-16 | 2003-05-16 | 27d | start no earlier than 2003-05-16 | NeuStar | 8h |
| 138 | 1.3.6.2 | Send out SP Profile Questionaire |  | 1d | 2003-05-26 | 2003-05-26 | 19d | start no earlier than 2003-05-26 | NeuStar | 8h |
| 139 | 1.3.6.3 | Preliminary Go/No Go decision |  | 1d | 2003-05-30 | 2003-05-30 | 15d | start no earlier than 2003-05-30 | NeuStar/Industry | 8h |
| 140 | 1.3.6.4 | SPs profile information due to NeuStar |  | 1d | 2003-06-02 | 2003-06-02 | 13d | start no earlier than 2003-06-02 | SPs; NeuStar | 16h |
| 141 | 1.3.6.5 | NPAC Taken down for H/w S/w install |  | 1d | 2003-06-15 | 2003-06-15 | 3d | start no earlier than 2003-06-15 | NeuStar | 8h |
| 142 | 1.3.6.6 | Regions 5,6 and 7 Final Go-NoGo decision | milestone | 0d | 2003-06-15 | 2003-06-15 | 4d | start no earlier than 2003-06-15 | SPs and NeuStar |  |
| 143 | 1.3.6.7 | Install Rel 3.2 Production Software |  | 1d | 2003-06-15 | 2003-06-15 | 3d | start no earlier than 2003-06-15 | NeuStar | 8h |
| 144 | 1.3.6.8 | Regions 5,6 and 7 General Availability | milestone | 0d | 2003-06-16 | 2003-06-16 | 3d | start no earlier than 2003-06-16 |  |  |
| 145 | 1.3.6.9 | Regions 5,6 and 7 Contigency Plan conference call |  | 1d | 2003-06-16 | 2003-06-16 | 2d | start no earlier than 2003-06-16 | SPs and NeuStar | 8h |
| 147 | 1.3.7 | Send Notice to clean up DPC and LRN data in existing SVs |  | 1d | 2003-06-18 | 2003-06-18 | 0d | start no earlier than 2003-06-18 |  |  |
| 149 | 1.4 | **SOW Close out** |  | 0d | 2003-06-16 | 2003-06-16 | 3d |  |  |  |
| 150 | 1.4.1 | Issue letter to PEs Results of Installation | milestone | 0d | 2003-06-16 | 2003-06-16 | 3d | start no earlier than 2003-06-16 | NeuStar |  |
| 151 | 1.4.2 | Post Mortem Conference Call | milestone | 0d | 2003-06-16 | 2003-06-16 | 3d | start no earlier than 2003-06-16 | NeuStar |  |
